# STYRENE PARK OFFSITE PROJECT

Schedule from MS Project, 2024-06-05 to 2025-05-14, status date 2024-11-25, A marks actual dates.

## Calendars

- 1158: Mon-Thu 07:30-13:00, 14:00-16:30; Fri 08:00-12:00, 13:00-17:00; Sat 07:30-13:00, 14:00-16:30; Sun off. Exceptions (off unless hours are given): 2024-07-15 to 2024-07-16 (تاسوعا عاشورا).

## Schedule

| ID | WBS | Task | Duration | Start | Finish | Predecessors | Complete | Remaining | Baseline start | Baseline finish | Baseline duration | Total slack | Free slack | Text1 | Text2 |
| --- | --- | --- | --- | --- | --- | --- | --- | --- | --- | --- | --- | --- | --- | --- | --- |
| 1 | 1 | START | 1d | 2024-06-05 A | 2024-06-05 A |  | 100% |  | 2024-06-05 | 2024-06-05 | 0d |  |  | 1403/3/16 | 1403/3/16 |
| 2 | 2 | **MILESTONE** | 1d | 2024-06-05 A | 2024-06-05 A |  | 100% |  | 2024-06-05 | 2024-06-05 | 0d |  |  | 1403/3/16 | 1403/3/16 |
| 3 | 2.1 | RECEIVE DOCUMENTS | 1d | 2024-06-05 A | 2024-06-05 A | 1 | 100% |  | 2024-06-05 | 2024-06-05 | 0d |  |  | 1403/3/16 | 1403/3/16 |
| 4 | 2.2 | ADVANCE PAYMENT | 1d | 2024-06-05 A | 2024-06-05 A | 1 | 100% |  | 2024-06-05 | 2024-06-05 | 0d |  |  | 1403/3/16 | 1403/3/16 |
| 5 | 3 | **ENGINEERING** | 120d | 2024-06-05 A | 2024-10-24 |  | 77% | 27.18d | 2024-06-05 | 2024-08-15 | 60d | 163d |  | 1403/3/16 | 1403/8/3 |
| 6 | 3.1 | **MAIN DOCUMENT** | 50d | 2024-06-05 A | 2024-08-03 |  | 91% | 4.43d | 2024-06-05 | 2024-07-05 | 27d | 17d |  | 1403/3/16 | 1403/5/13 |
| 7 | 3.1.1 | VENDOR PRINT INDEX SCHEDULE (VPIS) | 10d | 2024-06-05 A | 2024-06-15 A | 3, 4 | 100% |  | 2024-06-05 | 2024-06-20 | 14d |  |  | 1403/3/16 | 1403/3/26 |
| 8 | 3.1.2 | AIR COOLER THERMAL DATA SHEET | 9d | 2024-06-22 A | 2024-07-02 A | 3, 4 | 100% |  | 2024-06-05 | 2024-06-20 | 14d |  |  | 1403/4/2 | 1403/4/12 |
| 9 | 3.1.3 | GENERAL ARRANGEMENT DRAWING | 14d | 2024-07-01 A | 2024-07-18 | 8FS-8d |  | 14d | 2024-06-12 | 2024-06-27 | 14d | 31d |  | 1403/4/11 | 1403/4/28 |
| 10 | 3.1.4 | STEEL STRUCTURE CALCULATION | 25d | 2024-07-01 A | 2024-07-31 A | 8FS-7d | 100% |  | 2024-06-13 | 2024-06-28 | 14d |  |  | 1403/4/11 | 1403/5/10 |
| 11 | 3.1.5 | TUBE BUNDLE DRAWING | 50d | 2024-06-05 A | 2024-08-03 A | 8FS-8d, 9FS-8d | 100% |  | 2024-06-19 | 2024-07-04 | 14d |  |  | 1403/3/16 | 1403/5/13 |
| 12 | 3.1.6 | MECHANICAL CALCULATION | 50d | 2024-06-05 A | 2024-08-03 A | 8FS-7d, 9FS-7d | 100% |  | 2024-06-20 | 2024-07-05 | 14d |  |  | 1403/3/16 | 1403/5/13 |
| 13 | 3.2 | **DETAIL DOCUMENT** | 103d | 2024-06-22 A | 2024-10-22 |  | 88% | 12.77d | 2024-06-11 | 2024-08-15 | 55d | 0d |  | 1403/4/2 | 1403/8/1 |
| 14 | 3.2.1 | BUNDLE FRAME DRAWING | 14d | 2024-08-19 A | 2024-09-03 | 9FS-5d, 11FS-5d, 12FS-5d |  | 14d | 2024-07-01 | 2024-07-18 | 14d | 11d |  | 1403/5/29 | 1403/6/13 |
| 15 | 3.2.2 | FAN DRIVE ASSEMBLY DRAWING | 26d | 2024-08-10 A | 2024-09-09 A | 10FS-2d | 100% |  | 2024-06-27 | 2024-07-12 | 14d |  |  | 1403/5/20 | 1403/6/19 |
| 16 | 3.2.3 | FAN RING DRAWING | 25d | 2024-08-10 A | 2024-09-07 A | 10 | 100% |  | 2024-06-29 | 2024-07-17 | 14d |  |  | 1403/5/20 | 1403/6/17 |
| 17 | 3.2.4 | SUPPORT MECHANISM DRAWING | 25d | 2024-08-10 A | 2024-09-07 A | 10FS+2d | 100% |  | 2024-07-02 | 2024-07-19 | 14d |  |  | 1403/5/20 | 1403/6/17 |
| 18 | 3.2.5 | PLENUM DRAWING | 22d | 2024-08-14 A | 2024-09-07 A | 10FS+4d | 100% |  | 2024-07-04 | 2024-07-22 | 14d |  |  | 1403/5/24 | 1403/6/17 |
| 19 | 3.2.6 | NAME PLATE DRAWING | 9d | 2024-10-07 A | 2024-10-16 A | 9FS+26d | 100% |  | 2024-07-31 | 2024-08-15 | 14d |  |  | 1403/7/16 | 1403/7/25 |
| 20 | 3.2.7 | STEEL STRUCTURE DRAWING | 14d | 2024-09-16 A | 2024-10-01 | 10FS+3d |  | 14d | 2024-07-03 | 2024-07-20 | 14d | -68d | 0d | 1403/6/26 | 1403/7/10 |
| 21 | 3.2.8 | HEADER WALKWAY DRAWING | 14d | 2024-10-05 A | 2024-10-21 | 10FS+3d |  | 14d | 2024-07-03 | 2024-07-20 | 14d | -25d | 0d | 1403/7/14 | 1403/7/30 |
| 22 | 3.2.9 | LADDER DRAWING | 14d | 2024-10-06 A | 2024-10-22 | 10FS+3d |  | 14d | 2024-07-03 | 2024-07-20 | 14d | -26d | 0d | 1403/7/15 | 1403/8/1 |
| 23 | 3.2.10 | AXIAL FAN DATA SHEET | 23d | 2024-06-22 A | 2024-07-20 A | 8FS-9d | 100% |  | 2024-06-11 | 2024-06-26 | 14d |  |  | 1403/4/2 | 1403/4/30 |
| 24 | 3.2.11 | ELECTRICAL MOTOR DATA SHEET | 91d | 2024-06-22 A | 2024-10-08 | 8FS-9d | 99% | 0.91d | 2024-06-11 | 2024-06-26 | 14d | -14d | 0d | 1403/4/2 | 1403/7/17 |
| 25 | 3.2.12 | BELT & PULLEY DATA SHEET | 91d | 2024-06-22 A | 2024-10-08 A | 8FS-8d | 100% |  | 2024-06-12 | 2024-06-27 | 14d |  |  | 1403/4/2 | 1403/7/17 |
| 26 | 3.2.13 | VIBRATION SWITCH DATA SHEET | 91d | 2024-06-22 A | 2024-10-08 A | 8FS-6d | 100% |  | 2024-06-14 | 2024-06-29 | 14d |  |  | 1403/4/2 | 1403/7/17 |

| ID | WBS | Task | Type | Duration | Start | Finish | Predecessors | Complete | Remaining | Baseline start | Baseline finish | Baseline duration | Total slack | Free slack | Text1 | Text2 |
| --- | --- | --- | --- | --- | --- | --- | --- | --- | --- | --- | --- | --- | --- | --- | --- | --- |
| 27 | 3.3 | **GENERAL DOCUMENT** |  | 102d | 2024-06-26 A | 2024-10-24 |  | 55% | 45.48d | 2024-06-21 | 2024-08-13 | 44d | 163d |  | 1403/4/6 | 1403/8/3 |
| 28 | 3.3.1 | ELECTRICAL LOAD LIST |  | 18d | 2024-08-19 A | 2024-09-07 A | 24FS-3d, 23FS-3d | 100% |  | 2024-06-24 | 2024-07-09 | 14d |  |  | 1403/5/29 | 1403/6/17 |
| 29 | 3.3.2 | INSPECTION TEST PLAN (ITP) |  | 48d | 2024-07-29 A | 2024-09-22 A | 8 | 100% |  | 2024-06-21 | 2024-07-06 | 14d |  |  | 1403/5/8 | 1403/7/1 |
| 30 | 3.3.3 | WPS & PQR FOR PRESSURE PART AND STRUCTURE PART |  | 14d | 2024-08-26 A | 2024-09-10 | 29FS-7d |  | 14d | 2024-06-29 | 2024-07-17 | 14d | -28d | 0d | 1403/6/5 | 1403/6/20 |
| 31 | 3.3.4 | NDT PROCEDURE & WELD/NDT MAP |  | 14d | 2024-08-20 A | 2024-09-04 | 30FS+9d |  | 14d | 2024-07-29 | 2024-08-13 | 14d | 149d | 85d | 1403/5/30 | 1403/6/14 |
| 32 | 3.3.5 | SURFACE BLASTING & PAINTING & GALVANIZING SPECIFICATION AND INSPECTIONPROCEDURE |  | 8d | 2024-10-08 A | 2024-10-16 A | 29FS-5d | 100% |  | 2024-07-02 | 2024-07-19 | 14d |  |  | 1403/7/17 | 1403/7/25 |
| 33 | 3.3.6 | PWHT PROCEDURE |  | 6d | 2024-10-07 A | 2024-10-12 A | 29FS-4d | 100% |  | 2024-07-03 | 2024-07-20 | 14d |  |  | 1403/7/16 | 1403/7/21 |
| 34 | 3.3.7 | TUBE EXPANDING PROCEDURE |  | 14d | 2024-10-06 A | 2024-10-22 | 11 |  | 14d | 2024-07-05 | 2024-07-23 | 14d | 154d |  | 1403/7/15 | 1403/8/1 |
| 35 | 3.3.8 | PACKING & MARKING PROCEDURE |  | 9d | 2024-10-06 A | 2024-10-16 A | 29 | 100% |  | 2024-07-08 | 2024-07-25 | 14d |  |  | 1403/7/15 | 1403/7/25 |
| 36 | 3.3.9 | HYDROSTATIC TEST PROCEDURE |  | 14d | 2024-10-08 A | 2024-10-23 | 29FS+5d |  | 14d | 2024-07-13 | 2024-07-31 | 14d | 160d |  | 1403/7/17 | 1403/8/2 |
| 37 | 3.3.10 | N2 PURGING PROCEDURE |  | 5d | 2024-10-08 A | 2024-10-12 A | 29FS+6d | 100% |  | 2024-07-17 | 2024-08-01 | 14d |  |  | 1403/7/17 | 1403/7/21 |
| 38 | 3.3.11 | WELDER QUALIFICATION TEST CERTIFICATE |  | 2d | 2024-10-06 A | 2024-10-08 A | 30FS+6d | 100% |  | 2024-07-25 | 2024-08-09 | 14d |  |  | 1403/7/15 | 1403/7/17 |
| 39 | 3.3.12 | SITE RUN TEST PROCEDURE |  | 14d | 2024-10-08 A | 2024-10-23 | 11FS+8d |  | 14d | 2024-07-17 | 2024-08-01 | 14d | 163d |  | 1403/7/17 | 1403/8/2 |
| 40 | 3.3.13 | INSTALLATION , OPERATION & MAINTANENCE (MANUAL) |  | 14d | 2024-08-09 | 2024-08-24 | 8FS+30d |  |  | 2024-07-29 | 2024-08-13 | 14d | 215d |  | 1403/5/19 | 1403/6/3 |
| 41 | 3.3.14 | COMMISSIONING SPARE PART LIST |  | 14d | 2024-09-29 A | 2024-10-15 | 11FS+6d, 23FS+6d, 24FS+6d, 25FS+6d |  | 14d | 2024-07-12 | 2024-07-30 | 14d | -12d | 0d | 1403/7/8 | 1403/7/24 |
| 42 | 3.3.15 | 2-YEARS SPARE PART LIST |  | 14d | 2024-09-29 A | 2024-10-15 | 11FS-2d, 24FS-2d, 25FS-2d, 23FS-2d, 41FS-2d |  | 14d | 2024-07-29 | 2024-08-13 | 14d | 170d |  | 1403/7/8 | 1403/7/24 |
| 43 | 3.3.16 | SPECIAL TOOLS LIST |  | 3d | 2024-09-29 A | 2024-10-02 A | 11FS+10d | 100% |  | 2024-07-19 | 2024-08-03 | 14d |  |  | 1403/7/8 | 1403/7/11 |
| 44 | 3.3.17 | SUB VENDOR LIST |  | 49d | 2024-08-17 A | 2024-10-12 A | 8, 7 | 100% |  | 2024-06-21 | 2024-07-06 | 14d |  |  | 1403/5/27 | 1403/7/21 |
| 45 | 3.3.18 | TIME SCHEDULE |  | 26d | 2024-06-26 A | 2024-07-27 A | 7FS+5d | 100% |  | 2024-06-27 | 2024-07-12 | 14d |  |  | 1403/4/6 | 1403/5/6 |
| 46 | 3.3.19 | LUBRICANT CHART |  | 14d | 2024-10-09 | 2024-10-24 | 23, 24 |  |  | 2024-06-27 | 2024-07-12 | 14d | 162d |  | 1403/7/18 | 1403/8/3 |
| 47 | 3.3.20 | PACKING LIST |  | 14d | 2024-10-04 | 2024-10-19 | 29FS+10d |  |  | 2024-07-22 | 2024-08-06 | 14d | 166d | 82d | 1403/7/13 | 1403/7/28 |
| 48 | 4 | **PROCUREMENT** |  | 227d | 2024-07-24 A | 2025-04-14 |  | 26% | 167.54d | 2024-06-20 | 2025-01-22 | 184d | 26d |  | 1403/5/3 | 1404/1/25 |
| 49 | 4.1 | **LOCAL MATERIAL** |  | 146d | 2024-08-17 A | 2025-02-03 |  | 10% | 130.95d | 2024-06-28 | 2024-10-29 | 104d | 74d |  | 1403/5/27 | 1403/11/15 |
| 50 | 4.1.1 | PLATE FOR HEADER |  | 1d | 2024-08-17 A | 2024-08-17 A | 11, 12, 4, 44 | 100% |  | 2024-07-08 | 2024-08-01 | 20d |  |  | 1403/5/27 | 1403/5/27 |
| 51 | 4.1.2 | PLATE & PROFIL FOR MAIN STRUCTURES PARTS |  | 20d | 2024-10-22 A | 2024-11-13 | 4, 20 |  | 20d | 2024-07-22 | 2024-08-13 | 20d | 84d | 0d | 1403/8/1 | 1403/8/23 |
| 52 | 4.1.3 | PLATE & PROFIL FOR OTHERS STRUCTURES |  | 20d | 2024-10-22 A | 2024-11-13 | 20FS+25d, 4FS+25d, 15FS+25d, 16FS+25d, 17FS+25d, 18FS+25d, 21FS+25d, 22FS+25d |  | 20d | 2024-08-21 | 2024-09-12 | 20d | 64d | 0d | 1403/8/1 | 1403/8/23 |
| 53 | 4.1.4 | PLATE & PROFIL FOR BUNDLE FRAME |  | 20d | 2024-10-22 A | 2024-11-13 | 14FS+30d, 4FS+30d |  | 20d | 2024-08-23 | 2024-09-14 | 20d | 37d | 0d | 1403/8/1 | 1403/8/23 |
| 54 | 4.1.5 | PIPE |  | 20d | 2024-08-18 A | 2024-09-10 | 11FS+60d, 4FS+60d |  | 20d | 2024-09-16 | 2024-10-08 | 20d | 114d | 50d | 1403/5/28 | 1403/6/20 |
| 55 | 4.1.6 | GASKET | milestone | 0d | 2024-08-18 A | 2024-08-18 A | 11FS+30d, 12FS+30d, 4FS+30d | 100% |  | 2024-08-13 | 2024-09-04 | 20d |  |  | 1403/5/28 | 1403/5/28 |
| 56 | 4.1.7 | BOLT&NUT |  | 20d | 2024-08-18 A | 2024-09-10 | 11FS+30d, 20FS+30d, 4FS+30d |  | 20d | 2024-08-26 | 2024-09-17 | 20d | 190d |  | 1403/5/28 | 1403/6/20 |
| 57 | 4.1.8 | PLUG |  | 20d | 2024-10-22 A | 2024-11-13 | 11FS+30d, 4FS+30d |  | 20d | 2024-08-12 | 2024-09-03 | 20d | 135d |  | 1403/8/1 | 1403/8/23 |
| 58 | 4.1.9 | PAINT |  | 20d | 2024-11-11 A | 2024-12-03 | 11FS+50d, 4FS+50d |  | 20d | 2024-09-04 | 2024-09-26 | 20d | 111d | 47d | 1403/8/21 | 1403/9/13 |

| ID | WBS | Task | Type | Duration | Start | Finish | Predecessors | Complete | Remaining | Baseline start | Baseline finish | Baseline duration | Total slack | Free slack | Text1 | Text2 |
| --- | --- | --- | --- | --- | --- | --- | --- | --- | --- | --- | --- | --- | --- | --- | --- | --- |
| 59 | 4.1.10 | **FLANGES** |  | 70d | 2024-08-18 A | 2024-11-07 |  |  | 70d | 2024-07-03 | 2024-10-10 | 84d | 64d |  | 1403/5/28 | 1403/8/17 |
| 60 | 4.1.10.1 | FLANGES ( PO ) | milestone | 0d | 2024-08-18 A | 2024-08-18 A | 4, 12FS-3d | 100% |  | 2024-07-03 | 2024-07-20 | 14d |  |  | 1403/5/28 | 1403/5/28 |
| 61 | 4.1.10.2 | FLANGES (MANUFACTURING) |  | 60d | 2024-08-19 A | 2024-10-26 | 60 |  | 60d | 2024-07-22 | 2024-09-28 | 60d | 64d | 0d | 1403/5/29 | 1403/8/5 |
| 62 | 4.1.10.3 | FLANGES ( DELIVERY ) |  | 10d | 2024-10-28 | 2024-11-07 | 61 |  |  | 2024-09-30 | 2024-10-10 | 10d | 64d | 0d | 1403/8/7 | 1403/8/17 |
| 63 | 4.1.11 | **PULLEY** |  | 57.94d | 2024-10-22 A | 2024-12-27 |  | 40% | 34.81d | 2024-06-28 | 2024-10-29 | 104d | 106.06d |  | 1403/8/1 | 1403/10/7 |
| 64 | 4.1.11.1 | PULLEY ( PO ) |  | 1d | 2024-10-22 A | 2024-10-22 A | 25, 4 | 100% |  | 2024-06-28 | 2024-07-13 | 14d |  |  | 1403/8/1 | 1403/8/1 |
| 65 | 4.1.11.2 | PULLEY (MANUFACTURING) |  | 18.94d | 2024-11-01 A | 2024-11-22 A | 64 | 100% |  | 2024-07-17 | 2024-09-24 | 60d |  |  | 1403/8/11 | 1403/9/2 |
| 66 | 4.1.11.3 | PULLEY ( DELIVERY ) |  | 30d | 2024-11-22 | 2024-12-27 | 65 |  |  | 2024-09-25 | 2024-10-29 | 30d | 106.06d | 69.06d | 1403/9/2 | 1403/10/7 |
| 67 | 4.1.12 | **ALUM.TUBE** |  | 108d | 2024-10-01 A | 2025-02-03 |  | 16% | 90.84d | 2024-06-28 | 2024-10-29 | 104d | 60d |  | 1403/7/10 | 1403/11/15 |
| 68 | 4.1.12.1 | ALUM.TUBE ( PO ) |  | 17d | 2024-10-01 A | 2024-10-20 A | 9, 4 | 100% |  | 2024-06-28 | 2024-07-13 | 14d |  |  | 1403/7/10 | 1403/7/29 |
| 69 | 4.1.12.2 | ALUM.TUBE (MANUFACTURING) |  | 60d | 2024-10-22 A | 2024-12-30 | 68 |  | 60d | 2024-07-17 | 2024-09-24 | 60d | 60d | 0d | 1403/8/1 | 1403/10/10 |
| 70 | 4.1.12.3 | ALUM.TUBE ( DELIVERY) |  | 30d | 2024-12-31 | 2025-02-03 | 69 |  |  | 2024-09-25 | 2024-10-29 | 30d | 60d |  | 1403/10/11 | 1403/11/15 |
| 71 | 4.2 | **FOREIGN MATERIAL** |  | 227d | 2024-07-24 A | 2025-04-14 |  | 40% | 137.17d | 2024-06-20 | 2025-01-22 | 184d | 26d |  | 1403/5/3 | 1404/1/25 |
| 72 | 4.2.1 | **BASE TUBE** |  | 227d | 2024-07-24 A | 2025-04-14 |  | 13% | 197.97d | 2024-06-20 | 2024-12-30 | 164d | 0d |  | 1403/5/3 | 1404/1/25 |
| 73 | 4.2.1.1 | BASE TUBE( PO ) |  | 22d | 2024-07-24 A | 2024-08-17 A | 9FS-7d, 4 | 100% |  | 2024-06-20 | 2024-07-05 | 14d |  |  | 1403/5/3 | 1403/5/27 |
| 74 | 4.2.1.2 | BASE TUBE (MANUFACTURING) |  | 60d | 2024-10-22 A | 2024-12-30 | 73 |  | 60d | 2024-07-06 | 2024-09-16 | 60d | 0d |  | 1403/8/1 | 1403/10/10 |
| 75 | 4.2.1.3 | BASE TUBE (DELIVERY ) |  | 90d | 2024-12-31 | 2025-04-14 | 74 |  |  | 2024-09-17 | 2024-12-30 | 90d | 0d |  | 1403/10/11 | 1404/1/25 |
| 76 | 4.2.2 | **MOTOR** |  | 78d | 2024-07-24 A | 2024-10-22 A |  | 100% |  | 2024-07-08 | 2025-01-22 | 169d |  |  | 1403/5/3 | 1403/8/1 |
| 77 | 4.2.2.1 | MOTOR ( PO ) |  | 19d | 2024-07-24 A | 2024-08-14 A | 24, 4, 44 | 100% |  | 2024-07-08 | 2024-07-25 | 14d |  |  | 1403/5/3 | 1403/5/24 |
| 78 | 4.2.2.2 | MOTOR (MANUFACTURING) |  | 7.94d | 2024-08-15 A | 2024-08-23 A | 77 | 100% |  | 2024-07-26 | 2024-09-27 | 55d |  |  | 1403/5/25 | 1403/6/2 |
| 79 | 4.2.2.3 | MOTOR ( DELIVERY ) |  | 1d | 2024-10-22 A | 2024-10-22 A | 78 | 100% |  | 2024-09-28 | 2025-01-22 | 100d |  |  | 1403/8/1 | 1403/8/1 |
| 80 | 4.2.3 | **FAN** |  | 22d | 2024-07-24 A | 2024-08-18 A |  | 100% |  | 2024-07-08 | 2025-01-22 | 169d |  |  | 1403/5/3 | 1403/5/28 |
| 81 | 4.2.3.1 | FAN( PO) |  | 22d | 2024-07-24 A | 2024-08-18 A | 23, 4, 44 | 100% |  | 2024-07-08 | 2024-07-25 | 14d |  |  | 1403/5/3 | 1403/5/28 |
| 82 | 4.2.3.2 | FAN (MANUFACTURING) | milestone | 0d | 2024-08-18 A | 2024-08-18 A | 81 | 100% |  | 2024-07-26 | 2024-09-27 | 55d |  |  | 1403/5/28 | 1403/5/28 |
| 83 | 4.2.3.3 | FAN ( DELIVERY) | milestone | 0d | 2024-08-18 A | 2024-08-18 A | 82 | 100% |  | 2024-09-28 | 2025-01-22 | 100d |  |  | 1403/5/28 | 1403/5/28 |

| ID | WBS | Task | Duration | Start | Finish | Predecessors | Complete | Remaining | Baseline start | Baseline finish | Baseline duration | Total slack | Free slack | Text1 | Text2 |
| --- | --- | --- | --- | --- | --- | --- | --- | --- | --- | --- | --- | --- | --- | --- | --- |
| 84 | 4.2.4 | **VIBRATION SWITCH** | 204d | 2024-07-24 A | 2025-03-18 |  | 19% | 164.94d | 2024-07-08 | 2025-01-22 | 169d | 49d |  | 1403/5/3 | 1403/12/28 |
| 85 | 4.2.4.1 | VIBRATION SWITCH ( PO ) | 14d | 2024-07-24 A | 2024-08-08 | 26, 4, 44 |  | 14d | 2024-07-08 | 2024-07-25 | 14d | 239d |  | 1403/5/3 | 1403/5/18 |
| 86 | 4.2.4.2 | VIBRATION SWITCH (MANUFACTURING) | 27d | 2024-10-22 A | 2024-11-21 A | 85 | 100% |  | 2024-07-26 | 2024-09-27 | 55d |  |  | 1403/8/1 | 1403/9/1 |
| 87 | 4.2.4.3 | VIBRATION SWITCH ( DELIVERY ) | 100d | 2024-11-22 | 2025-03-18 | 86 |  |  | 2024-09-28 | 2025-01-22 | 100d | 37d | 0d | 1403/9/2 | 1403/12/28 |
| 88 | 4.2.5 | **BELT** | 84d | 2024-08-19 A | 2024-11-24 A |  | 100% |  | 2024-07-08 | 2025-01-22 | 169d |  |  | 1403/5/29 | 1403/9/4 |
| 89 | 4.2.5.1 | BELT( PO ) | 54d | 2024-08-19 A | 2024-10-20 A | 25, 4, 44 | 100% |  | 2024-07-08 | 2024-07-25 | 14d |  |  | 1403/5/29 | 1403/7/29 |
| 90 | 4.2.5.2 | BELT (MANUFACTURING) | 12.94d | 2024-11-01 A | 2024-11-15 A | 89 | 100% |  | 2024-07-26 | 2024-09-27 | 55d |  |  | 1403/8/11 | 1403/8/25 |
| 91 | 4.2.5.3 | BELT ( DELIVERY ) | 7d | 2024-11-16 A | 2024-11-24 A | 90 | 100% |  | 2024-09-28 | 2025-01-22 | 100d |  |  | 1403/8/26 | 1403/9/4 |
| 92 | 5 | **MANUFACTURING** | 193d | 2024-09-18 A | 2025-04-30 |  | 13% | 166.96d | 2024-08-06 | 2025-01-17 | 142d | 0d |  | 1403/6/28 | 1404/2/10 |
| 93 | 5.1 | **FABRICATION** | 189d | 2024-09-18 A | 2025-04-25 |  | 15% | 160.68d | 2024-08-06 | 2025-01-10 | 136d | 0d |  | 1403/6/28 | 1404/2/5 |
| 94 | 5.1.1 | **HEADER** | 113d | 2024-09-18 A | 2025-01-27 |  | 31% | 77.44d | 2024-08-06 | 2024-12-30 | 126d | 64d |  | 1403/6/28 | 1403/11/8 |
| 95 | 5.1.1.1 | CUTTING | 5d | 2024-09-18 A | 2024-09-23 A | 50FS+3d | 100% |  | 2024-08-06 | 2024-09-09 | 30d |  |  | 1403/6/28 | 1403/7/2 |
| 96 | 5.1.1.2 | PRIMERY FITUP HEADER | 7d | 2024-10-01 A | 2024-10-08 A | 95FS-20d | 100% |  | 2024-08-17 | 2024-09-20 | 30d |  |  | 1403/7/10 | 1403/7/17 |
| 97 | 5.1.1.3 | HEADERS INTERNAL WELDING | 12d | 2024-10-06 A | 2024-10-20 A | 96FS-20d, 38 | 100% |  | 2024-08-29 | 2024-10-02 | 30d |  |  | 1403/7/15 | 1403/7/29 |
| 98 | 5.1.1.4 | HEADERS EXTERNAL WELDING | 11.94d | 2024-10-19 A | 2024-11-01 A | 97FS-15d, 38 | 100% |  | 2024-09-16 | 2024-10-19 | 30d |  |  | 1403/7/28 | 1403/8/11 |
| 99 | 5.1.1.5 | HEADERS DRILLING | 21d | 2024-10-31 A | 2024-11-23 A | 98FS-15d | 100% |  | 2024-10-03 | 2024-11-06 | 30d |  |  | 1403/8/10 | 1403/9/3 |
| 100 | 5.1.1.6 | HEADERS END PLATE FITUP & WELDING | 30d | 2024-11-01 | 2024-12-05 | 99FS-20d, 38 |  |  | 2024-10-15 | 2024-11-18 | 30d | 80d | 16d | 1403/8/11 | 1403/9/15 |
| 101 | 5.1.1.7 | NOZZLE FLANGES PREPARATION | 30d | 2024-11-08 | 2024-12-12 | 62, 54 |  |  | 2024-10-11 | 2024-11-14 | 30d | 64d | 0d | 1403/8/18 | 1403/9/22 |
| 102 | 5.1.1.8 | NOZZLE FLANGES FITUP / WELDING IN HEADERS | 25d | 2024-12-13 | 2025-01-10 | 100FS-10d, 101, 31, 38 |  |  | 2024-11-15 | 2024-12-13 | 25d | 64d | 0d | 1403/9/23 | 1403/10/21 |
| 103 | 5.1.1.9 | NDT TEST | 25d | 2024-12-13 | 2025-01-10 | 102SS, 97 |  |  | 2024-11-15 | 2024-12-13 | 25d | 64d | 0d | 1403/9/23 | 1403/10/21 |
| 104 | 5.1.1.10 | PWHT | 14d | 2025-01-11 | 2025-01-27 | 103, 33 |  |  | 2024-12-14 | 2024-12-30 | 14d | 64d | 0d | 1403/10/22 | 1403/11/8 |
| 105 | 5.1.2 | **BUNDLE FRAME** | 84d | 2024-11-22 | 2025-02-27 |  |  |  | 2024-09-24 | 2024-12-30 | 84d | 37d |  | 1403/9/2 | 1403/12/9 |
| 106 | 5.1.2.1 | CUTTING BUNDLE FRAMES | 30d | 2024-11-22 | 2024-12-26 | 53FS+7d |  |  | 2024-09-24 | 2024-10-28 | 30d | 37d | 0d | 1403/9/2 | 1403/10/6 |
| 107 | 5.1.2.2 | FITUP / WELDING BUNDLE FRAMES | 39d | 2025-01-14 | 2025-02-27 | 106FS+15d |  |  | 2024-11-15 | 2024-12-30 | 39d | 37d | 0d | 1403/10/25 | 1403/12/9 |

| ID | WBS | Task | Duration | Start | Finish | Predecessors | Baseline start | Baseline finish | Baseline duration | Total slack | Free slack | Text1 | Text2 |
| --- | --- | --- | --- | --- | --- | --- | --- | --- | --- | --- | --- | --- | --- |
| 108 | 5.1.3 | **STEEL STRUCTURES** | 70d | 2024-11-14 | 2025-02-03 |  | 2024-08-14 | 2024-12-03 | 96d | 64d |  | 1403/8/24 | 1403/11/15 |
| 109 | 5.1.3.1 | MAIN STRUCTURES STEEL STRUCTURES FABRICATION | 50d | 2024-11-14 | 2025-01-10 | 51, 38 | 2024-08-14 | 2024-10-10 | 50d | 84d | 0d | 1403/8/24 | 1403/10/21 |
| 110 | 5.1.3.2 | OTHER STRUCTURES STEEL STRUCTURES FABRICATION | 70d | 2024-11-14 | 2025-02-03 | 52, 38 | 2024-09-13 | 2024-12-03 | 70d | 64d | 0d | 1403/8/24 | 1403/11/15 |
| 111 | 5.1.4 | **FIN TUBE** | 10d | 2025-04-15 | 2025-04-25 |  | 2024-12-31 | 2025-01-10 | 10d | 0d |  | 1404/1/26 | 1404/2/5 |
| 112 | 5.1.4.1 | FIN TUBE FABRICATION | 10d | 2025-04-15 | 2025-04-25 | 70, 75 | 2024-12-31 | 2025-01-10 | 10d | 0d |  | 1404/1/26 | 1404/2/5 |
| 113 | 5.2 | **COATING** | 48d | 2025-01-11 | 2025-03-07 |  | 2024-10-11 | 2025-01-07 | 76d | 43d |  | 1403/10/22 | 1403/12/17 |
| 114 | 5.2.1 | HEADERS COATING | 7d | 2025-01-28 | 2025-02-04 | 104, 58, 32 | 2024-12-31 | 2025-01-07 | 7d | 64d |  | 1403/11/9 | 1403/11/16 |
| 115 | 5.2.2 | BUNDLE FRAMES COATING | 7d | 2025-02-28 | 2025-03-07 | 107, 32 | 2024-12-31 | 2025-01-07 | 7d | 37d |  | 1403/12/10 | 1403/12/17 |
| 116 | 5.2.3 | MAIN STRUCTURES COATING | 7d | 2025-01-11 | 2025-01-18 | 109, 32 | 2024-10-11 | 2024-10-18 | 7d | 84d | 0d | 1403/10/22 | 1403/10/29 |
| 117 | 5.2.4 | OTHER STRUCTURESCOATING | 7d | 2025-02-04 | 2025-02-11 | 110, 32 | 2024-12-04 | 2024-12-11 | 7d | 64d | 0d | 1403/11/16 | 1403/11/23 |
| 118 | 5.3 | **ASSEMBLING OF TUBE BUNDLE** | 7d | 2025-04-21 | 2025-04-28 |  | 2025-01-08 | 2025-01-15 | 7d | 0d |  | 1404/2/1 | 1404/2/8 |
| 119 | 5.3.1 | ASSEMBLING OF TUBE BUNDLE PARTS | 7d | 2025-04-21 | 2025-04-28 | 112FS-5d, 114, 115, 55, 56, 19, 57, 34, 37 | 2025-01-08 | 2025-01-15 | 7d | 0d |  | 1404/2/1 | 1404/2/8 |
| 120 | 5.4 | **TESTS** | 7d | 2025-04-23 | 2025-04-30 |  | 2025-01-10 | 2025-01-17 | 7d | 0d |  | 1404/2/3 | 1404/2/10 |
| 121 | 5.4.1 | HYDRO TESTS | 7d | 2025-04-23 | 2025-04-30 | 119FS-5d, 36FS-5d | 2025-01-10 | 2025-01-17 | 7d | 0d |  | 1404/2/3 | 1404/2/10 |
| 122 | 6 | **INSPECTION** | 91d | 2025-01-20 | 2025-05-05 |  | 2024-10-19 | 2025-01-27 | 86d | 0d |  | 1403/11/1 | 1404/2/15 |
| 123 | 6.1 | MAIN STRUCTURES | 4d | 2025-01-20 | 2025-01-23 | 116 | 2024-10-19 | 2024-10-23 | 4d | 84d | 0d | 1403/11/1 | 1403/11/4 |
| 124 | 6.2 | OTHER STRUCTURES | 4d | 2025-02-12 | 2025-02-15 | 117 | 2024-12-12 | 2024-12-16 | 4d | 64d | 0d | 1403/11/24 | 1403/11/27 |
| 125 | 6.3 | TUBE BUNDLE | 4d | 2025-05-01 | 2025-05-05 | 121 | 2025-01-18 | 2025-01-22 | 4d | 0d |  | 1404/2/11 | 1404/2/15 |
| 126 | 6.4 | MACHINERY EQUIPMENT & INSTRUMENT PARTS | 4d | 2025-03-19 | 2025-03-22 | 79, 83, 87, 91, 66 | 2025-01-23 | 2025-01-27 | 4d | 37d | 0d | 1403/12/29 | 1404/1/2 |
| 127 | 7 | **PACKING & MARKING & TRANSPORT TO THE SITE** | 88d | 2025-01-24 | 2025-05-06 |  | 2024-10-24 | 2025-01-28 | 83d | 0d |  | 1403/11/5 | 1404/2/16 |
| 128 | 7.1 | MAIN STRUCTURES | 4d | 2025-01-24 | 2025-01-28 | 123, 35, 47 | 2024-10-24 | 2024-10-28 | 4d | 84d |  | 1403/11/5 | 1403/11/9 |
| 129 | 7.2 | OTHER STRUCTURES | 4d | 2025-02-17 | 2025-02-20 | 124, 35, 47 | 2024-12-17 | 2024-12-20 | 4d | 64d |  | 1403/11/29 | 1403/12/2 |
| 130 | 7.3 | TUBE BUNDLE | 4d | 2025-05-02 | 2025-05-06 | 125FS-3d, 35, 47 | 2025-01-20 | 2025-01-23 | 4d | 0d |  | 1404/2/12 | 1404/2/16 |
| 131 | 7.4 | MACHINERY EQUIPMENT & INSTRUMENT PARTS | 4d | 2025-03-20 | 2025-03-24 | 126FS-3d, 35FS-3d, 47FS-3d | 2025-01-24 | 2025-01-28 | 4d | 37d |  | 1404/1/1 | 1404/1/4 |

| ID | WBS | Task | Type | Duration | Start | Finish | Predecessors | Baseline start | Baseline finish | Baseline duration | Total slack | Text1 | Text2 |
| --- | --- | --- | --- | --- | --- | --- | --- | --- | --- | --- | --- | --- | --- |
| 132 | 8 | **FINAL BOOK** |  | 11d | 2025-05-02 | 2025-05-14 |  | 2025-01-24 | 2025-02-05 | 11d | 0d | 1404/2/12 | 1404/2/24 |
| 133 | 8.1 | FINAL DATA BOOK INDEX |  | 11d | 2025-05-02 | 2025-05-14 | 128FS-4d, 129FS-4d, 130FS-4d, 131FS-4d, 39, 43, 42, 45, 46 | 2025-01-24 | 2025-02-05 | 11d | 0d | 1404/2/12 | 1404/2/24 |
| 134 | 8.2 | FINAL DATA BOOK |  | 10d | 2025-05-03 | 2025-05-14 | 133FS-10d, 28, 40 | 2025-01-25 | 2025-02-05 | 10d | 0d | 1404/2/13 | 1404/2/24 |
| 135 | 9 | FINISH | milestone | 0d | 2025-05-14 | 2025-05-14 | 134 | 2025-02-05 | 2025-02-05 | 0d | 0d | 1404/2/24 | 1404/2/24 |
